# Home Construction

Schedule from Primavera P6, 2018-10-09 to 2019-01-31, data date 2018-10-24, costs in USD, A marks actual dates.

## Calendars

- Calendar 1: Mon off; Tue-Sat 09:00-14:00, 15:00-19:00; Sun off.

## Resources

| Resource | Group | Unit | Rate |
| --- | --- | --- | --- |
| Daniel Muller | labor |  | 55 |
| Land Surveyor | labor |  | 65 |
| Excavator | labor |  | 70 |
| Process Operations | labor |  |  |
| Laborer Construction | labor |  | 18 |
| Ironworker | labor |  | 49 |
| Finish Carpenter | labor |  | 52 |
| Concrete | material | CY | 10 |
| Mason | labor |  | 10 |
| Laborer-Construction | labor |  | 18 |
| Plumber | labor |  | 58 |
| Finishes & Fit-out Subcontractor | labor |  | 49 |
| Richard Collins | labor |  | 40 |
| Electrician | labor |  | 52 |
| Glass & Glazing Subcontractor | labor |  | 70 |
| Landscaping Subcontractor | labor |  | 72 |

## Schedule

| ID | WBS | Activity | Type | Duration | Start | Finish | Predecessors | Complete | Remaining | Planned start | Planned finish | Total float | Free float | Resources | Cost | Actual cost |
| --- | --- | --- | --- | --- | --- | --- | --- | --- | --- | --- | --- | --- | --- | --- | --- | --- |
| A1000 |  | Project Start | milestone | 0d | 2018-10-09 A | 2018-10-09 A |  | 100% |  |  |  |  |  |  |  |  |
| A1010 |  | Project Management | level of effort | 85d | 2018-10-09 A | 2019-01-31 | A1000 SS | 5% | 81d | 2018-10-09 | 2019-01-22 | 0d |  | Daniel Muller [680 h] | 37,400 |  |
| A1020 |  | Project Complete | milestone | 0d | 2019-01-31 | 2019-01-31 | A1010 FF, A1170, A1190, A1230, A1260, A1170 FF, A1190 FF, A1230 FF, A1260 FF |  |  |  |  | 0d |  |  |  |  |
|  | 1 | **Grading** |  |  | 2018-10-09 | 2018-10-24 |  |  |  |  |  |  |  |  |  |  |
| A1030 |  | Survey and mark out site |  | 3d | 2018-10-09 A | 2018-10-11 A | A1000 SS | 100% |  |  |  |  |  | Land Surveyor [24 h] | 1,560 | 1,560 |
| A1040 |  | Site Demarcation |  | 1d | 2018-10-11 A | 2018-10-12 A | A1030 | 100% |  |  |  |  |  | Land Surveyor [8 h] | 520 | 520 |
| A1050 |  | Excavation | resource dependent | 3d | 2018-10-12 A | 2018-10-17 A | A1040 | 100% |  |  |  |  |  | Excavator [21 h] | 1,470 | 1,470 |
| A1060 |  | Grade Site |  | 2d | 2018-10-17 A | 2018-10-24 A | A1050 | 100% |  | 2018-10-17 | 2018-10-18 |  |  | Process Operations [16 h] |  |  |
|  | 2 | **Foundation** |  |  | 2018-10-23 | 2018-11-02 |  |  |  |  |  |  |  |  |  |  |
| A1070 |  | Laying of Foundation |  | 4d | 2018-10-23 A | 2018-10-26 A |  | 100% |  |  |  |  |  | Laborer Construction [32 h]; Ironworker [32 h]; Finish Carpenter [32 h]; Concrete [32 CY]; Mason [32 h]; Laborer-Construction [32 h] | 5,024 | 5,024 |
| A1080 |  | Slab Plumbing |  | 7d | 2018-10-26 A | 2018-11-01 | A1070 |  | 7d | 2018-10-26 | 2018-11-03 | 0d |  | Plumber [56 h] | 3,248 |  |
| A1090 |  | Pour and Float Slab Concrete |  | 2d | 2018-11-01 | 2018-11-02 | A1080 |  |  |  |  | 0d |  | Concrete [16 CY] | 160 |  |
|  | 3 | **Structure** |  |  | 2018-10-24 | 2019-01-31 |  |  |  |  |  |  |  |  |  |  |
|  | 1 | **Framing** |  |  | 2018-11-03 | 2019-01-04 |  |  |  |  |  |  |  |  |  |  |
| A1100 |  | Exterior Walls |  | 20d | 2018-11-03 | 2018-11-28 | A1090 |  |  |  |  | 0d |  | Mason [160 h]; Finishes & Fit-out Subcontractor [160 h] | 1,600 |  |
| A1110 |  | Interior Walls |  | 25d | 2018-11-28 | 2018-12-28 | A1100 |  |  |  |  | 27d |  | Mason [200 h]; Finishes & Fit-out Subcontractor [200 h] | 2,000 |  |
| A1120 |  | Exterior Cladding |  | 30d | 2018-11-28 | 2019-01-04 | A1100 |  |  |  |  | 0d |  | Finishes & Fit-out Subcontractor [240 h]; Mason [240 h] | 2,400 |  |
|  | 2 | **Roof** |  |  | 2018-11-28 | 2019-01-02 |  |  |  |  |  |  |  |  |  |  |
| A1130 |  | Truss Placing |  | 15d | 2018-11-28 | 2018-12-18 | A1100 |  |  |  |  | 19d | 0d | Ironworker [120 h] | 5,880 |  |
| A1140 |  | Roof Sheeting |  | 10d | 2018-12-18 | 2018-12-28 | A1130 |  |  |  |  | 19d | 0d | Laborer Construction [80 h]; Laborer-Construction [80 h] | 2,880 |  |
| A1150 |  | Place Paper and Shingles |  | 3d | 2018-12-29 | 2019-01-02 | A1140 |  |  |  |  | 19d | 0d | Laborer Construction [24 h]; Laborer-Construction [24 h] | 864 |  |
|  | 3 | **Interior** |  |  | 2018-10-24 | 2019-01-09 |  |  |  |  |  |  |  |  |  |  |
|  | 1 | **Mechnical** |  |  | 2019-01-02 | 2019-01-09 |  |  |  |  |  |  |  |  |  |  |
| A1160 |  | HVAC Ducting |  | 3d | 2019-01-02 | 2019-01-05 | A1150 |  |  |  |  | 19d | 0d | Richard Collins [24 h] | 960 |  |
| A1170 |  | Install HVAC Unit |  | 2d | 2019-01-05 | 2019-01-09 | A1160, A1160 SS |  |  |  |  | 19d |  | Richard Collins [16 h] | 640 |  |

| ID | WBS | Activity | Duration | Start | Finish | Predecessors | Total float | Free float | Resources | Cost |
| --- | --- | --- | --- | --- | --- | --- | --- | --- | --- | --- |
|  | 2 | **Electrical** |  | 2018-11-28 | 2018-12-13 |  |  |  |  |  |
| A1180 |  | Breaker Box and Rough Wire | 5d | 2018-11-28 | 2018-12-05 | A1100 | 40d | 0d | Electrician [40 h] | 2,080 |
| A1190 |  | Finish Wiring | 7d | 2018-12-05 | 2018-12-13 | A1180 | 40d |  | Electrician [56 h] | 2,912 |
|  | 3 | **Plumbing** |  | 2018-11-28 | 2018-12-11 |  |  |  |  |  |
| A1200 |  | Install Rough plumbing lines | 10d | 2018-11-28 | 2018-12-11 | A1100 | 28d | 0d | Plumber [80 h] | 4,640 |
|  | 4 | **Decor** |  | 2018-10-24 | 2018-12-28 |  |  |  |  |  |
| A1230 |  | Kitchen Cabinets | 10d | 2018-10-24 | 2018-11-03 |  | 71d |  | Finish Carpenter [80 h] | 4,160 |
| A1210 |  | Placing Doors | 8d | 2018-12-11 | 2018-12-20 | A1200 | 28d | 0d | Finish Carpenter [64 h] | 3,328 |
| A1220 |  | Door Casings and Baseboards | 6d | 2018-12-20 | 2018-12-28 | A1210 | 28d |  | Finish Carpenter [48 h] | 2,496 |
|  | 5 | **Exterior** |  | 2019-01-04 | 2019-01-25 |  |  |  |  |  |
| A1240 |  | Place Windows | 12d | 2019-01-04 | 2019-01-19 | A1120 | 0d |  | Glass & Glazing Subcontractor [96 h]; Finish Carpenter [96 h] | 4,992 |
| A1250 |  | Window Sidings | 5d | 2019-01-19 | 2019-01-25 | A1240 | 0d |  | Finish Carpenter [40 h] | 2,080 |
|  | 4 | **Landscaping** |  | 2019-01-25 | 2019-01-31 |  |  |  |  |  |
| A1260 |  | Tree Plantings | 5d | 2019-01-25 | 2019-01-31 | A1250 | 0d |  | Landscaping Subcontractor [40 h] |  |

## Risks

| ID | Risk | Status |
| --- | --- | --- |
| RISK1 | Non availability of masonry crew | RS_Propose |
| RISK2 | Non availability of roof sheeting manpower | RS_Propose |

## Issues

| Issue | Status | Raised |
| --- | --- | --- |
| Start Date Variance (days) is 0 on WBS: CD00720 | IS_Open | 2018-10-09 |
| Start Date Variance (days) is 0 on WBS: CD00720.1 | IS_Open | 2018-10-09 |
| Start Date Variance (days) is 0 on WBS: CD00720.2 | IS_Open | 2018-10-09 |
| Start Date Variance (days) is 0 on WBS: CD00720.3 | IS_Open | 2018-10-09 |
| Start Date Variance (days) is 0 on WBS: CD00720.3.1 | IS_Open | 2018-10-09 |
| Start Date Variance (days) is 0 on WBS: CD00720.3.2 | IS_Open | 2018-10-09 |
| Start Date Variance (days) is 0 on WBS: CD00720.3.3 | IS_Open | 2018-10-09 |
| Start Date Variance (days) is 0 on WBS: CD00720.3.3.1 | IS_Open | 2018-10-09 |
| Start Date Variance (days) is 0 on WBS: CD00720.3.3.2 | IS_Open | 2018-10-09 |
| Start Date Variance (days) is 0 on WBS: CD00720.3.3.3 | IS_Open | 2018-10-09 |
| Start Date Variance (days) is 0 on WBS: CD00720.3.3.4 | IS_Open | 2018-10-09 |
| Start Date Variance (days) is 0 on WBS: CD00720.3.5 | IS_Open | 2018-10-09 |
| Start Date Variance (days) is 0 on WBS: CD00720.3.4 | IS_Open | 2018-10-09 |
